# Проект1Венета_ТРТ

Schedule from MS Project, 2014-11-10 to 2015-02-18.
SPecialiST RePack

## Calendars

- Стандартный: Mon-Fri 09:00-13:00, 14:00-18:00; Sat-Sun off.

## Schedule

| ID | WBS | Task | Type | Duration | Start | Finish | Total slack |
| --- | --- | --- | --- | --- | --- | --- | --- |
| 1 | 1 | **Бизнес анализ** |  | 10d | 2014-11-10 | 2014-11-21 |  |
| 2 | 1.1 | Проведение интервью с ключевым сотрудником | manual | 1d? | 2014-11-10 | 2014-11-10 |  |
| 5 | 2 | **Постановка задачи внедрения** |  | 21d | 2014-11-21 | 2014-12-19 |  |
| 6 | 2.1 | **Разработка ТЗ** |  | 13.88d | 2014-11-21 | 2014-12-10 | 0d |
| 7 | 2.1.1 | Написание ТЗ | manual | 9d | 2014-11-21 | 2014-12-03 |  |
| 8 | 2.1.2 | Согласование с заказчиком | manual | 1d | 2014-12-05 | 2014-12-05 |  |
| 9 | 2.1.3 | Доработки по результатам согласования | manual | 3d | 2014-12-08 | 2014-12-10 |  |
| 10 | 2.2 | **Разработка алгоритмов и функций первого этапа** |  | 6d | 2014-12-05 | 2014-12-12 |  |
| 11 | 2.2.1 | Разработка функций переходов по статусам | manual | 1d | 2014-12-05 | 2014-12-05 |  |
| 12 | 2.2.2 | Разработка периодических функций | manual | 1d | 2014-12-08 | 2014-12-08 |  |
| 13 | 2.2.3 | Разработка автоматического создания заявок на платеж, счетов | manual | 2d | 2014-12-09 | 2014-12-10 |  |
| 14 | 2.2.4 | Разработка создания задач и сообщений при переходе в статус | manual | 2d | 2014-12-10 | 2014-12-11 |  |
| 15 | 2.3 | **Разработка методологии тестирования первого этапа** |  | 6d | 2014-12-12 | 2014-12-19 |  |
| 16 | 2.3.1 | Разработка методологии тестирования переходов по статусам | manual | 1d | 2014-12-12 | 2014-12-12 |  |
| 17 | 2.3.2 | Разработка методологии тестирования сообщений и задач | manual | 1d | 2014-12-15 | 2014-12-15 |  |
| 18 | 2.3.3 | Разработка методологии тестирования периодических процессов | manual | 2d | 2014-12-16 | 2014-12-17 |  |
| 19 | 2.3.4 | Разработка методологии тестирования создания заявок на платеж, счетов | manual | 2d | 2014-12-18 | 2014-12-19 |  |
| 20 | 2.4 | Заключение контракта с заказчиком | manual | 1d | 2014-11-21 | 2014-11-21 |  |
| 21 | 3 | **Разработка ИО первого этапа** |  | 5d | 2014-12-19 | 2014-12-25 |  |
| 22 | 3.1 | **Настройка полей ИО** |  | 1d | 2014-12-19 | 2014-12-19 |  |
| 23 | 3.1.1 | Настройка полей ТРТ | manual | 1d | 2014-12-19 | 2014-12-19 |  |
| 24 | 3.1.2 | Настройка полей Лот ТРТ | manual | 1d | 2014-12-19 | 2014-12-19 |  |
| 25 | 3.2 | Создание и настройка справочников | manual | 1d | 2014-12-22 | 2014-12-22 |  |
| 26 | 3.3 | Настройка переходов по статусам | manual | 1d | 2014-12-22 | 2014-12-22 |  |
| 27 | 3.4 | Настройка доступов к объектам | manual | 3d | 2014-12-23 | 2014-12-25 |  |

| ID | WBS | Task | Type | Duration | Start | Finish | Total slack |
| --- | --- | --- | --- | --- | --- | --- | --- |
| 28 | 4 | **Реализация функций для первого этапа** |  | 16d | 2015-01-12 | 2015-02-02 |  |
| 29 | 4.1 | Релизация функций переходов по статусам | manual | 4d | 2015-01-12 | 2015-01-15 |  |
| 30 | 4.2 | Реализация функций периодических процессов | manual | 4d | 2015-01-16 | 2015-01-21 |  |
| 31 | 4.3 | Реализация функций сообщений и задач | manual | 4d | 2015-01-22 | 2015-01-27 |  |
| 32 | 4.4 | Реализация создания заявок на платеж, счетов | manual | 4d | 2015-01-28 | 2015-02-02 |  |
| 33 | 5 | **Внедрение первого этапа** |  | 14d | 2015-02-01 | 2015-02-18 |  |
| 34 | 5.1 | **Настройка ИО по ролям** |  | 0d? | 2015-02-01 | 2015-02-01 | 0d |
| 35 | 5.1.1 | Настройка доступа для сотрудника КО | manual | 1d | 2015-02-01 | 2015-02-01 |  |
| 36 | 5.1.2 | Настройка доступа для руководителя тендерного отдела | manual | 1d? | 2015-02-01 | 2015-02-01 |  |
| 37 | 5.1.3 | Настройка доступа для директора холдинга | manual | 1d? | 2015-02-01 | 2015-02-01 |  |
| 38 | 5.1.4 | Настройка доступа для сотрудника тендерного отдела | manual | 1d? | 2015-02-01 | 2015-02-01 |  |
| 39 | 5.2 | **Тестирование ИО по ролям** |  | 0d? | 2015-02-01 | 2015-02-01 | 0d |
| 40 | 5.2.1 | Тестирование доступов по ролям | manual | 1d? | 2015-02-01 | 2015-02-01 |  |
| 41 | 5.2.2 | Тестирование функций задач и сообщений | manual | 1d? | 2015-02-01 | 2015-02-01 |  |
| 42 | 5.2.3 | Тестирование функций перехода по статусам | manual | 1d? | 2015-02-01 | 2015-02-01 |  |
| 43 | 5.2.4 | Тестирование функций периодических процессов | manual | 1d? | 2015-02-01 | 2015-02-01 |  |
| 44 | 5.2.5 | Тестирование функций создания заявок на платеж | manual | 1d? | 2015-02-01 | 2015-02-01 |  |
| 45 | 5.3 | Доработки | manual | 1d? | 2015-02-01 | 2015-02-01 |  |
| 46 | 5.4 | Прохождение контрольной проверки | manual | 1d? | 2015-02-01 | 2015-02-01 |  |
| 47 | 5.5 | Обучение сотрудников | manual | 1d? | 2015-02-01 | 2015-02-01 |  |
| 48 | 5.6 | Запуск первого этапа | manual | 1d? | 2015-02-01 | 2015-02-01 |  |
